Schedule from Planner, 2004-09-24 to 2008-01-07.

## Calendars

- Default: Mon-Fri 08:00-12:00, 13:00-17:00; Sat-Sun off.

## Schedule

| ID | WBS | Task | Type | Duration | Start | Finish | Predecessors | Constraint | Work |
| --- | --- | --- | --- | --- | --- | --- | --- | --- | --- |
| 1 | 1 | **Commissioning** |  |  | 2004-09-24 | 2005-12-30 |  |  | 2648h |
| 2 | 1.1 | Switch ordered | milestone | 0d | 2004-09-24 | 2004-09-24 |  | must start on 2004-09-24 |  |
| 3 | 1.2 | Arrives | milestone | 0d | 2005-01-01 | 2005-01-01 | 2 | must start on 2005-01-01 |  |
| 4 | 1.3 | Nodes ordered | milestone | 0d | 2004-12-01 | 2004-12-01 |  | must start on 2004-12-01 |  |
| 5 | 1.4 | Arrives | milestone | 0d | 2005-03-01 | 2005-03-01 | 4 | must start on 2005-03-01 |  |
| 6 | 1.5 | **Stage 1** |  |  | 2005-04-01 | 2005-07-08 | 3, 5 |  | 568h |
| 7 | 1.5.1 | Step 1 |  |  | 2005-04-01 | 2005-04-07 |  | must start on 2005-04-01 | 40h |
| 8 | 1.5.2 | Step 2 |  |  | 2005-05-01 | 2005-07-08 | 7 | must start on 2005-05-01 | 400h |
| 9 | 1.6 | Stage 2 |  |  | 2005-07-08 | 2005-11-18 | 6 |  | 760h |
| 10 | 1.7 | **Stage 3** |  |  | 2005-09-01 | 2005-12-30 |  |  | 696h |
| 11 | 1.7.1 | 1st disk lot ordered | milestone | 0d | 2005-09-01 | 2005-09-01 |  | start no earlier than 2005-09-01 |  |
| 12 | 1.7.2 | Step 2 |  |  | 2005-11-21 | 2005-12-30 | 9, 11 | must start on 2005-11-21 | 240h |
| 13 | 2 | **Production** |  |  | 2005-12-30 | 2007-12-31 | 1 |  | 4168h |
| 14 | 2.1 | H/W maintenance |  |  | 2005-12-30 | 2007-12-28 |  |  | 4160h |
| 15 | 2.2 | First Light | milestone | 0d | 2006-01-01 | 2006-01-01 |  | must start on 2006-01-01 |  |
| 16 | 2.3 | 2nd disk purchase | milestone | 0d | 2006-06-01 | 2006-06-01 |  | must start on 2006-06-01 |  |
| 17 | 2.4 | Disk testing |  |  | 2006-08-01 | 2006-08-28 | 16 | must start on 2006-08-01 | 160h |
| 18 | 2.5 | 3rd disk purchase | milestone | 0d | 2007-03-01 | 2007-03-01 |  | must start on 2007-03-01 |  |
| 19 | 2.6 | Disk testing |  |  | 2007-05-01 | 2007-05-28 | 18 | must start on 2007-05-01 | 160h |
| 20 | 2.7 | End of Ref. Mission | milestone | 0d | 2008-01-01 | 2008-01-01 |  | must start on 2008-01-01 |  |
| 21 | 3 | End of Life |  |  | 2008-01-01 | 2008-01-07 | 13 |  | 40h |
